# PLANLAMA sondan basa

Schedule from MS Project, 2010-04-12 to 2010-08-20.
TOKI Halkalı tum Bolgeler Sure Analizi
TEK-ART

## Calendars

- Standard: Mon-Fri 08:00-12:00, 13:00-17:00; Sat-Sun off.

## Schedule

| ID | WBS | Task | Duration | Start | Finish | Predecessors | Baseline start | Baseline finish | Baseline duration | Total slack | Free slack |
| --- | --- | --- | --- | --- | --- | --- | --- | --- | --- | --- | --- |
| 1 | 1 | **BİR BLOK TUM İSLER** | 95d? | 2010-04-12 | 2010-08-20 |  | 2004-11-10 | 2005-03-22 | 95d? | 0d |  |
| 2 | 1.1 | **TEMEL IMALATI** | 20d | 2010-04-12 | 2010-05-07 |  | 2004-11-10 | 2004-12-07 | 20d | 0d |  |
| 3 | 1.1.1 | Temel Aplikasyonu | 1d | 2010-04-12 | 2010-04-12 |  | 2004-11-10 | 2004-11-10 | 1d | 0d |  |
| 4 | 1.1.2 | Temel kazısı | 2d | 2010-04-12 | 2010-04-13 | 3SS | 2004-11-10 | 2004-11-11 | 2d | 0d |  |
| 5 | 1.1.3 | Grobeton dökülmesi | 1d | 2010-04-14 | 2010-04-14 | 4 | 2004-11-12 | 2004-11-12 | 1d | 0d |  |
| 6 | 1.1.4 | Temel su izolasyonu(3mm) | 1d | 2010-04-15 | 2010-04-15 | 5 | 2004-11-15 | 2004-11-15 | 1d | 0d |  |
| 7 | 1.1.5 | Koruma betonu(5cm) | 1d | 2010-04-16 | 2010-04-16 | 6 | 2004-11-16 | 2004-11-16 | 1d | 0d |  |
| 8 | 1.1.6 | Radye Temel(kalıp+demir+beton) | 4d | 2010-04-20 | 2010-04-23 | 7FS+1d | 2004-11-18 | 2004-11-23 | 4d | 0d |  |
| 9 | 1.1.7 | Temel drenajı | 3h | 2010-05-07 | 2010-05-07 | 18, 10 | 2004-12-07 | 2004-12-07 | 3h | 75.62d |  |
| 10 | 1.1.8 | Bodrum kat su izolasyonu | 1d | 2010-05-06 | 2010-05-06 | 18FS+1d | 2004-12-06 | 2004-12-06 | 1d | 75d | 0d |
| 11 | 1.1.9 | Geri dolgu | 1d | 2010-05-07 | 2010-05-07 | 10 | 2004-12-07 | 2004-12-07 | 1d | 75d |  |
| 12 | 1.2 | **BETONARME İMALATLAR** | 33d | 2010-04-27 | 2010-06-10 |  | 2004-11-25 | 2005-01-10 | 33d | 0d |  |
| 13 | 1.2.1 | Bodrum kat (Kalıp,demir,beton) | 4d | 2010-04-27 | 2010-04-30 | 8FS+1d | 2004-11-25 | 2004-11-30 | 4d | 0d |  |
| 14 | 1.2.2 | Zemin+N.Katlar (Kalıp+demir+beton) | 24d | 2010-05-04 | 2010-06-04 | 13FS+1d | 2004-12-02 | 2005-01-04 | 24d | 0d |  |
| 15 | 1.2.3 | Balkon prekast montajı | 3d | 2010-06-04 | 2010-06-08 | 14FF+2d | 2005-01-04 | 2005-01-06 | 3d | 49d | 0d |
| 16 | 1.2.4 | Çatı prekast montajı | 1d | 2010-06-10 | 2010-06-10 | 14FS+3d | 2005-01-10 | 2005-01-10 | 1d | 42d | 0d |
| 17 | 1.2.5 | Merdiven imalatı | 14d | 2010-05-20 | 2010-06-08 | 14FF+2d | 2004-12-20 | 2005-01-06 | 14d | 53d |  |
| 18 | 1.2.6 | Kapama perdeleri | 2d | 2010-05-03 | 2010-05-04 | 13 | 2004-12-01 | 2004-12-02 | 2d | 75d | 0d |
| 19 | 1.2.7 | Bina girişleri (markiz) (kalıp demir beton) | 7d | 2010-05-18 | 2010-05-26 | 14SS+10d | 2004-12-16 | 2004-12-24 | 7d | 62d |  |
| 20 | 1.3 | **DUVAR İŞLERİ** | 20d | 2010-05-26 | 2010-06-22 |  | 2004-12-24 | 2005-01-20 | 20d | 0d |  |
| 21 | 1.3.1 | İç duvar işlerinin tamamlanması | 15d | 2010-05-26 | 2010-06-15 | 14FF+7d | 2004-12-24 | 2005-01-13 | 15d | 0d |  |
| 22 | 1.3.2 | Dış duvar işlerinin tamamlanması | 10d | 2010-06-02 | 2010-06-15 | 14FF+7d | 2004-12-31 | 2005-01-13 | 10d | 0d |  |
| 23 | 1.3.3 | Bacaların yapımı | 4d | 2010-06-15 | 2010-06-18 | 21FF+3d | 2005-01-13 | 2005-01-18 | 4d | 43d | 0d |
| 24 | 1.3.4 | Çatı baca ve sıvalarının yapımı | 2d | 2010-06-21 | 2010-06-22 | 23 | 2005-01-19 | 2005-01-20 | 2d | 43d |  |

| ID | WBS | Task | Duration | Start | Finish | Predecessors | Baseline start | Baseline finish | Baseline duration | Total slack | Free slack |
| --- | --- | --- | --- | --- | --- | --- | --- | --- | --- | --- | --- |
| 25 | 1.4 | **SIVA ÖNCESİ İŞLER** | 24d | 2010-05-28 | 2010-06-30 |  | 2004-12-28 | 2005-01-28 | 24d | 6d |  |
| 26 | 1.4.1 | Pissu kolon ve yatay boruların montajı | 15d | 2010-06-01 | 2010-06-21 | 21FF+4d | 2004-12-30 | 2005-01-19 | 15d | 44d |  |
| 27 | 1.4.2 | Temizsu kolon ve yatay boruların montajı | 15d | 2010-06-01 | 2010-06-21 | 21FF+4d | 2004-12-30 | 2005-01-19 | 15d | 41d | 27d |
| 28 | 1.4.3 | Doğalgaz tesisatının yapılması | 15d | 2010-06-01 | 2010-06-21 | 21FF+4d | 2004-12-30 | 2005-01-19 | 15d | 44d |  |
| 29 | 1.4.4 | Yangın söndürme sistemi ana hatlarının döşenmesi | 7d | 2010-06-11 | 2010-06-21 | 21FF+4d | 2005-01-11 | 2005-01-19 | 7d | 44d |  |
| 30 | 1.4.5 | Elektrik boş borularının döşenmesi ve kontrolü | 10d | 2010-06-08 | 2010-06-21 | 14SS, 21FF+4d | 2005-01-06 | 2005-01-19 | 10d | 22d | 0d |
| 31 | 1.4.6 | PVC Doğrama kör kasa yapımı ve montajı | 14d | 2010-06-10 | 2010-06-29 | 21FS-4d | 2005-01-10 | 2005-01-27 | 14d | 0d |  |
| 32 | 1.4.7 | Mermer denizlikler | 13d | 2010-06-14 | 2010-06-30 | 31SS+2d | 2005-01-12 | 2005-01-28 | 13d | 37d |  |
| 33 | 1.4.8 | Saç kapı kasalarının montajı ve dolgusu | 12d | 2010-06-01 | 2010-06-16 | 21SS+4d | 2004-12-30 | 2005-01-14 | 12d | 4d | 0d |
| 34 | 1.4.9 | Tüm perdelerin düzgünlüğünün tesbiti ve tamiri | 12d | 2010-06-01 | 2010-06-16 | 33SS | 2004-12-30 | 2005-01-14 | 12d | 47d | 0d |
| 35 | 1.4.10 | Yatay kılıflı borunun döşenmesi | 15d | 2010-05-28 | 2010-06-17 | 21SS+2d | 2004-12-28 | 2005-01-17 | 15d | 34d |  |
| 36 | 1.4.11 | Boru geçişlerinin etraflarının sıvanması | 7d | 2010-06-08 | 2010-06-16 | 34FF, 21SS+3d | 2005-01-06 | 2005-01-14 | 7d | 47d |  |
| 37 | 1.5 | **ÇATI İŞLERİ** | 9d | 2010-06-11 | 2010-06-23 |  | 2005-01-11 | 2005-01-21 | 9d | 42d |  |
| 38 | 1.5.1 | Çatı karkası | 4d | 2010-06-11 | 2010-06-16 | 16 | 2005-01-11 | 2005-01-14 | 4d | 42d | 0d |
| 39 | 1.5.2 | CTP veye çinko işleri | 2d | 2010-06-17 | 2010-06-18 | 38 | 2005-01-17 | 2005-01-18 | 2d | 42d | 0d |
| 40 | 1.5.3 | İzolasyon işleri | 1d | 2010-06-18 | 2010-06-18 | 39FF | 2005-01-18 | 2005-01-18 | 1d | 42d | 0d |
| 41 | 1.5.4 | Çatı örtüsü (Kiremit-Mahya Kaplama) | 3d | 2010-06-21 | 2010-06-23 | 40 | 2005-01-19 | 2005-01-21 | 3d | 42d |  |
| 42 | 1.6 | **İÇ SIVA İŞLERİ** | 28d | 2010-06-03 | 2010-07-12 |  | 2005-01-03 | 2005-02-09 | 28d | 4d |  |
| 43 | 1.6.1 | Banyo-wc kaba sıvasının yapılması | 15d | 2010-06-03 | 2010-06-23 | 33SS+2d | 2005-01-03 | 2005-01-21 | 15d | 29d | 0d |
| 44 | 1.6.2 | İç sıvaların yapılması | 15d | 2010-06-03 | 2010-06-23 | 33SS+2d | 2005-01-03 | 2005-01-21 | 15d | 4d | 0d |
| 45 | 1.6.3 | Banyo-wc su izolasyonu yapılması | 5d | 2010-06-03 | 2010-06-09 | 43SS | 2005-01-03 | 2005-01-07 | 5d | 52d |  |
| 46 | 1.6.4 | Şap yapımı | 10d | 2010-06-15 | 2010-06-28 | 44FF+3d | 2005-01-13 | 2005-01-26 | 10d | 4d | 0d |
| 47 | 1.6.5 | İzolasyon işleri+alçıpan yapımı | 15d | 2010-06-22 | 2010-07-12 | 46SS+5d | 2005-01-20 | 2005-02-09 | 15d | 23d | 18d |
| 48 | 1.6.6 | Alçı sıva yoklama ve yapımı | 15d | 2010-06-22 | 2010-07-12 | 46SS+5d | 2005-01-20 | 2005-02-09 | 15d | 6d | 0d |

| ID | WBS | Task | Duration | Start | Finish | Predecessors | Baseline start | Baseline finish | Baseline duration | Total slack | Free slack |
| --- | --- | --- | --- | --- | --- | --- | --- | --- | --- | --- | --- |
| 49 | 1.7 | **DIŞ SIVA İŞLERİ** | 25d | 2010-06-09 | 2010-07-13 |  | 2005-01-07 | 2005-02-10 | 25d | 8d |  |
| 50 | 1.7.1 | Tamirat ve dolgu yapımı | 2d | 2010-06-21 | 2010-06-22 | 22FS+3d | 2005-01-19 | 2005-01-20 | 2d | 0d |  |
| 51 | 1.7.2 | Dış sıva yapımı | 5d | 2010-06-23 | 2010-06-29 | 50 | 2005-01-21 | 2005-01-27 | 5d | 0d |  |
| 52 | 1.7.3 | Balkon korkuluğu yapımı | 4d | 2010-06-09 | 2010-06-14 | 15 | 2005-01-07 | 2005-01-12 | 4d | 49d |  |
| 53 | 1.7.4 | Düşey yağmur borusu | 2d | 2010-06-30 | 2010-07-01 | 51 | 2005-01-28 | 2005-01-31 | 2d | 36d |  |
| 54 | 1.7.5 | Dış cephe boyası | 10d | 2010-06-30 | 2010-07-13 | 51, 46 | 2005-01-28 | 2005-02-10 | 10d | 3d |  |
| 55 | 1.8 | **DOGRAMA İMALALARI** | 22d | 2010-06-16 | 2010-07-15 |  | 2005-01-14 | 2005-02-14 | 22d | 10d |  |
| 56 | 1.8.1 | PVC pencerelerin ve kapıların takılması | 10d | 2010-06-30 | 2010-07-13 | 31, 51 | 2005-01-28 | 2005-02-10 | 10d | 0d |  |
| 57 | 1.8.2 | silikon | 2d | 2010-07-14 | 2010-07-15 | 56 | 2005-02-11 | 2005-02-14 | 2d | 26d |  |
| 58 | 1.8.3 | Yangın kapılarının montajı | 5d | 2010-06-16 | 2010-06-22 | 22 | 2005-01-14 | 2005-01-20 | 5d | 43d |  |
| 59 | 1.8.4 | Çelik kapıların takılması | 5d | 2010-07-06 | 2010-07-12 | 48FF | 2005-02-03 | 2005-02-09 | 5d | 26d | 0d |
| 60 | 1.8.5 | Merdiven korkuluklarının montajı | 10d | 2010-06-16 | 2010-06-29 | 22 | 2005-01-14 | 2005-01-27 | 10d | 38d |  |
| 61 | 1.8.6 | Fayans | 10d | 2010-06-17 | 2010-06-30 | 43FF+5d | 2005-01-17 | 2005-01-28 | 10d | 29d | 0d |
| 62 | 1.8.7 | Seramik yapılması | 10d | 2010-06-22 | 2010-07-05 | 46FF+5d | 2005-01-20 | 2005-02-02 | 10d | 29d | 0d |
| 63 | 1.8.8 | Karo yapımı | 4d | 2010-06-23 | 2010-06-28 | 46FF | 2005-01-21 | 2005-01-26 | 4d | 39d |  |
| 64 | 1.9 | **ASANSOR İMALATI** | 35d | 2010-06-07 | 2010-07-23 |  | 2005-01-05 | 2005-01-27 | 17d | 20d |  |
| 65 | 1.9.1 | Asansör süspansiyon betonlarının atılması | 2d | 2010-06-07 | 2010-06-08 | 14 | 2005-01-05 | 2005-01-06 | 2d | 48d | 0d |
| 66 | 1.9.2 | Asansör ray montajı | 11d | 2010-06-07 | 2010-07-20 | 14 | 2005-01-05 | 2005-01-18 | 10d | 20d | 0d |
| 67 | 1.9.3 | Asansör kapılarının montajı | 5d | 2010-06-16 | 2010-06-22 | 21 | 2005-01-14 | 2005-01-20 | 5d | 38d | 0d |
| 68 | 1.9.4 | Kabin montajı | 3d | 2010-07-21 | 2010-07-23 | 66 | 2005-01-19 | 2005-01-21 | 3d | 20d |  |
| 69 | 1.9.5 | Asansör kapı kenarları duvar ve sıvası | 2d | 2010-06-23 | 2010-06-24 | 67 | 2005-01-21 | 2005-01-24 | 2d | 41d |  |
| 70 | 1.9.6 | Katlarda asansör iç kapılarının montajı | 5d | 2010-06-23 | 2010-06-29 | 67 | 2005-01-21 | 2005-01-27 | 5d | 38d |  |
| 71 | 1.9.7 | Makine dairesi montajı | 5d | 2010-06-09 | 2010-06-15 | 65 | 2005-01-07 | 2005-01-13 | 5d | 48d |  |
| 72 | 1.10 | **ELEKTRİK MONTAJ** | 30d | 2010-06-22 | 2010-08-02 |  | 2005-01-20 | 2005-03-02 | 30d | 14d |  |
| 73 | 1.10.1 | Tesisat kablolarının çekilmesi | 10d | 2010-06-22 | 2010-07-05 | 30 | 2005-01-20 | 2005-02-02 | 10d | 22d | 17d |
| 74 | 1.10.2 | Tablo,sayaç montajı,v.b | 3d | 2010-07-29 | 2010-08-02 | 81FF+1d, 73, 27 | 2005-02-28 | 2005-03-02 | 3d | 14d |  |

| ID | WBS | Task | Duration | Start | Finish | Predecessors | Baseline start | Baseline finish | Baseline duration | Total slack | Free slack |
| --- | --- | --- | --- | --- | --- | --- | --- | --- | --- | --- | --- |
| 75 | 1.11 | **BOYA VE ONCESİ IMALATLAR** | 37d | 2010-06-18 | 2010-08-09 |  | 2005-01-18 | 2005-03-09 | 37d | 9d |  |
| 76 | 1.11.1 | Mermer eşik | 3d | 2010-07-13 | 2010-07-15 | 46, 59 | 2005-02-10 | 2005-02-14 | 3d | 26d |  |
| 77 | 1.11.2 | Basamak kaplama işleri | 10d | 2010-06-18 | 2010-07-01 | 46SS+3d | 2005-01-18 | 2005-01-31 | 10d | 36d |  |
| 78 | 1.11.3 | Mermer Kaplama yapılması | 1d | 2010-06-29 | 2010-06-29 | 46 | 2005-01-27 | 2005-01-27 | 1d | 38d |  |
| 79 | 1.11.4 | Çift cam takılması | 5d | 2010-07-14 | 2010-07-20 | 56, 54FF+2d | 2005-02-11 | 2005-02-17 | 5d | 0d |  |
| 80 | 1.11.5 | Plastik boya (tavan-duvar) | 14d | 2010-07-21 | 2010-08-09 | 48FF+5d, 79 | 2005-02-18 | 2005-03-09 | 14d | 0d |  |
| 81 | 1.11.6 | İnce akrilik Boya (duvar) | 14d | 2010-07-13 | 2010-07-30 | 48 | 2005-02-10 | 2005-03-01 | 14d | 6d | 0d |
| 82 | 1.11.7 | Fasarit (Tavan) | 4d | 2010-07-13 | 2010-07-16 | 48 | 2005-02-10 | 2005-02-15 | 4d | 25d |  |
| 83 | 1.11.8 | Kapı Kanatları | 7d | 2010-07-28 | 2010-08-05 | 33, 81FF+4d | 2005-02-25 | 2005-03-07 | 7d | 6d |  |
| 84 | 1.11.9 | Şaft kapağı ve muhtelif işler | 3d | 2010-07-13 | 2010-07-15 | 48 | 2005-02-10 | 2005-02-14 | 3d | 24d | 0d |
| 85 | 1.12 | **MEKANİK MONTAJ** | 29d? | 2010-07-06 | 2010-08-13 |  | 2005-02-03 | 2005-03-15 | 29d? | 5d |  |
| 86 | 1.12.1 | Radyatör ve vana montajı ve branşman tesisatı | 7d | 2010-08-05 | 2010-08-13 | 80FF+4d, 35 | 2005-03-07 | 2005-03-15 | 7d | 0d |  |
| 87 | 1.12.2 | Duş teknesi, Alaturka hela taşı montajı | 5d? | 2010-07-06 | 2010-07-12 | 62 | 2005-02-03 | 2005-02-09 | 5d? | 29d |  |
| 88 | 1.12.3 | Su sayaçları montajı | 2d? | 2010-07-16 | 2010-07-19 | 84 | 2005-02-15 | 2005-02-16 | 2d? | 24d |  |
| 89 | 1.13 | **AKSESUAR MONTAJ** | 37d? | 2010-07-01 | 2010-08-20 |  | 2005-01-31 | 2005-03-22 | 37d? | 0d |  |
| 90 | 1.13.1 | Mutfak dolaplarının takılması | 6d? | 2010-08-06 | 2010-08-13 | 80FF+4d, 47 | 2005-03-08 | 2005-03-15 | 6d? | 5d |  |
| 91 | 1.13.2 | Anahtar,priz ,buton ve armatürlerin montajı | 7d? | 2010-08-05 | 2010-08-13 | 80FF+4d, 73 | 2005-03-07 | 2005-03-15 | 7d? | 0d |  |
| 92 | 1.13.3 | İç kapıların madeni aksamlarının takılması | 7d? | 2010-08-05 | 2010-08-13 | 33, 80FF+4d | 2005-03-07 | 2005-03-15 | 7d? | 0d |  |
| 93 | 1.13.4 | Buzlu cam takılması | 2d? | 2010-08-12 | 2010-08-13 | 92FF | 2005-03-14 | 2005-03-15 | 2d? | 5d |  |
| 94 | 1.13.5 | Asma tavan altı bitümlü astar badana | 1d | 2010-07-01 | 2010-07-01 | 61 | 2005-01-31 | 2005-01-31 | 1d | 29d | 0d |
| 95 | 1.13.6 | Alüminyum asma tavan | 7d | 2010-07-02 | 2010-07-12 | 61, 94 | 2005-02-01 | 2005-02-09 | 7d | 29d |  |
| 96 | 1.13.7 | Vitrifiye,armatür montajı | 4d? | 2010-07-01 | 2010-07-06 | 61 | 2005-01-31 | 2005-02-03 | 4d? | 33d |  |
| 97 | 1.13.8 | Bina içlerinin temizliği | 9d? | 2010-08-05 | 2010-08-17 | 83FF+2d, 86FF+2d, 91FF+2d, 92FF+2d | 2005-03-07 | 2005-03-17 | 9d? | 0d |  |
| 98 | 1.13.9 | Halı serilmesi | 7d? | 2010-08-12 | 2010-08-20 | 97FF+3d | 2005-03-14 | 2005-03-22 | 7d? | 0d |  |
